# Children's Book Schedule

How a schedule from MS Project changed from version to version. A marks actual dates.

## Version 1 (saved 2010-06-02, file Advanced Plan_Start.mpp)

| ID | WBS | Task | Duration | Start | Finish | Predecessors | Total float | Constraint |
| --- | --- | --- | --- | --- | --- | --- | --- | --- |
| 1 | 1 | **Editorial staff meeting** | 60.12d | 2012-04-09 08:00 | 2012-07-02 09:00 |  | 93.88d |  |
| 2 |  | Editorial staff meeting 1 | 1h | 2012-04-09 08:00 | 2012-04-09 09:00 |  | 153d | start no earlier than 2012-04-09 08:00 |
| 3 |  | Editorial staff meeting 2 | 1h | 2012-04-16 08:00 | 2012-04-16 09:00 |  | 148d | start no earlier than 2012-04-16 08:00 |
| 4 |  | Editorial staff meeting 3 | 1h | 2012-04-23 08:00 | 2012-04-23 09:00 |  | 143d | start no earlier than 2012-04-23 08:00 |
| 5 |  | Editorial staff meeting 4 | 1h | 2012-04-30 08:00 | 2012-04-30 09:00 |  | 138d | start no earlier than 2012-04-30 08:00 |
| 6 |  | Editorial staff meeting 5 | 1h | 2012-05-07 08:00 | 2012-05-07 09:00 |  | 133d | start no earlier than 2012-05-07 08:00 |
| 7 |  | Editorial staff meeting 6 | 1h | 2012-05-14 08:00 | 2012-05-14 09:00 |  | 128d | start no earlier than 2012-05-14 08:00 |
| 8 |  | Editorial staff meeting 7 | 1h | 2012-05-21 08:00 | 2012-05-21 09:00 |  | 123d | start no earlier than 2012-05-21 08:00 |
| 9 |  | Editorial staff meeting 8 | 1h | 2012-05-28 08:00 | 2012-05-28 09:00 |  | 118d | start no earlier than 2012-05-28 08:00 |
| 10 |  | Editorial staff meeting 9 | 1h | 2012-06-04 08:00 | 2012-06-04 09:00 |  | 113d | start no earlier than 2012-06-04 08:00 |
| 11 |  | Editorial staff meeting 10 | 1h | 2012-06-11 08:00 | 2012-06-11 09:00 |  | 108d | start no earlier than 2012-06-11 08:00 |
| 12 |  | Editorial staff meeting 11 | 1h | 2012-06-18 08:00 | 2012-06-18 09:00 |  | 103d | start no earlier than 2012-06-18 08:00 |
| 13 |  | Editorial staff meeting 12 | 1h | 2012-06-25 08:00 | 2012-06-25 09:00 |  | 98d | start no earlier than 2012-06-25 08:00 |
| 14 |  | Editorial staff meeting 13 | 1h | 2012-07-02 08:00 | 2012-07-02 09:00 |  | 93d | start no earlier than 2012-07-02 08:00 |
| 15 | 2 | **Acquisition** | 30d | 2012-04-02 08:00 | 2012-05-11 17:00 |  | -0.75d |  |
| 16 |  | Manuscript received | 0d | 2012-04-02 08:00 | 2012-04-02 08:00 |  | -9.5d |  |
| 17 |  | Content edit | 15d | 2012-04-02 08:00 | 2012-04-25 17:00 | 16 | -9.5d |  |
| 18 |  | Author review of content edit | 12d | 2012-04-26 08:00 | 2012-05-11 17:00 | 17 | -9.5d |  |
| 19 |  | Handoff to Editorial | 0d | 2012-05-11 17:00 | 2012-05-11 17:00 | 18 | -9.5d |  |
| 20 | 3 | **Editorial** | 30d | 2012-05-10 08:00 | 2012-06-20 17:00 | 15 |  |  |
| 21 |  | Organize manuscript for copyedit | 5d | 2012-05-10 08:00 | 2012-05-16 17:00 |  | 1.25d |  |
| 22 |  | Copyedit | 11.25d | 2012-05-17 08:00 | 2012-06-01 10:00 | 21 | 1.25d |  |
| 23 |  | Author review of copyedit | 10d | 2012-06-01 10:00 | 2012-06-15 10:00 | 22 | 1.25d |  |
| 24 |  | Copyedit incorp | 5d | 2012-06-12 15:00 | 2012-06-19 15:00 | 23FS-2.5% | 1.25d |  |
| 25 |  | Handoff to Production | 0d | 2012-06-19 15:00 | 2012-06-19 15:00 | 24 | 1.25d |  |
| 26 | 4 | **Design and Production** | 50d | 2012-06-21 08:00 | 2012-08-30 17:00 | 20 | 7d |  |
| 27 |  | Set pages | 15d | 2012-06-21 08:00 | 2012-07-12 17:00 |  | 7d |  |
| 28 |  | Interior illustration design | 15d | 2012-06-21 08:00 | 2012-07-12 17:00 | 27SS | 7d |  |
| 29 | 4.3 | **1st Pages review** | 25d | 2012-07-13 08:00 | 2012-08-16 17:00 | 28 | 7d |  |
| 30 |  | Proofread and index | 10d | 2012-07-13 08:00 | 2012-07-26 17:00 |  | 33d | start no earlier than 2012-07-13 08:00 |
| 31 |  | Incorporate 1st Pages review | 5d | 2012-07-27 08:00 | 2012-08-02 17:00 | 30 | 7d |  |
| 32 |  | Send proofed pages to Production | 0d | 2012-08-02 17:00 | 2012-08-02 17:00 | 31 | 7d |  |
| 33 |  | Enter page corrections and index | 5d | 2012-08-03 08:00 | 2012-08-09 17:00 | 32 | 7d |  |
| 34 |  | Cover design | 5d | 2012-08-10 08:00 | 2012-08-16 17:00 | 33 | 7d |  |
| 35 | 4.4 | **2nd Pages review** | 10d | 2012-08-17 08:00 | 2012-08-30 17:00 |  | 7d |  |
| 36 |  | Proof and review | 5d | 2012-08-17 08:00 | 2012-08-23 17:00 | 34 | 7d |  |
| 37 |  | Send proofed pages to Production | 0d | 2012-08-23 17:00 | 2012-08-23 17:00 | 36 | 7d |  |
| 38 |  | Final review | 5d | 2012-08-24 08:00 | 2012-08-30 17:00 | 37 | 7d |  |
| 39 | 4.5 | **Design book's companion website** | 5d | 2012-08-17 08:00 | 2012-08-23 17:00 | 29 | 12d |  |
| 40 |  | Create mockup | 3d | 2012-08-17 08:00 | 2012-08-21 17:00 |  | 12d |  |
| 41 |  | Review with author | 2d | 2012-08-22 08:00 | 2012-08-23 17:00 | 40 | 12d |  |
| 42 | 5 | **Color prep and printing** | 50d | 2012-09-03 08:00 | 2012-11-09 17:00 | 39 |  |  |
| 43 |  | Send to color house | 1d | 2012-09-03 08:00 | 2012-09-03 17:00 | 35 | 4d |  |
| 44 |  | Generate proofs | 10d | 2012-09-04 08:00 | 2012-09-17 17:00 | 43 | 6d |  |
| 45 |  | Print and ship | 30d | 2012-09-21 08:00 | 2012-11-01 17:00 | 44FS+3d | 6d |  |
| 46 | 6 | **Book launch prep** | 17d | 2012-08-24 08:00 | 2012-09-17 17:00 |  | 39d |  |
| 47 |  | Launch planning | 5d | 2012-08-24 08:00 | 2012-08-30 17:00 | 39 | 39d |  |
| 48 |  | Assign launch team members | 1d | 2012-08-31 08:00 | 2012-08-31 17:00 | 47 | 39d |  |
| 49 |  | Complete author questionnaire | 5d | 2012-09-03 08:00 | 2012-09-07 17:00 | 48 | 39d |  |
| 50 |  | Schedule author interviews | 1d | 2012-09-10 08:00 | 2012-09-10 17:00 | 49 | 39d |  |
| 51 |  | Design and order marketing material | 5d | 2012-09-11 08:00 | 2012-09-17 17:00 | 50 | 39d |  |

## Version 2 (saved 2010-06-02, file Advanced Tracking D_Start.mpp)

Last finish 2012-11-09 → 2012-11-22 (+13d). Complete tasks 0 → 19.

Added:

| ID | Task | Duration | Start | Finish | Predecessors | Resources |
| --- | --- | --- | --- | --- | --- | --- |
| 18 | Original art review | 10.25d | 2012-04-19 10:00 A | 2012-05-03 12:00 A | 17FS-5d | Hany Morcos; Jane Dow |

Changed:

| ID | Task | Start | Finish | Duration | Complete | Total float | Predecessors | Other |
| --- | --- | --- | --- | --- | --- | --- | --- | --- |
| 1 | **Editorial staff meeting** | 2012-04-09 08:00 A |  |  | 0% → 54% | 93.88d → 102.88d |  | baseline start none → 2012-04-09 08:00; baseline finish none → 2012-07-02 09:00 |
| 2 | Editorial staff meeting 1 | 2012-04-09 08:00 A | 2012-04-09 09:00 A |  | 0% → 100% | 153d → none |  | resources Carole Poland; Jun Cao; Hany Morcos → Carole Poland; Jun Cao; Hany Morcos; Dan Jump [50%]; baseline start none → 2012-04-09 08:00; baseline finish none → 2012-04-09 09:00 |
| 3 | Editorial staff meeting 2 | 2012-04-16 08:00 A | 2012-04-16 09:00 A |  | 0% → 100% | 148d → none |  | resources Carole Poland; Jun Cao; Hany Morcos → Carole Poland; Jun Cao; Hany Morcos; Dan Jump [50%]; baseline start none → 2012-04-16 08:00; baseline finish none → 2012-04-16 09:00 |
| 4 | Editorial staff meeting 3 | 2012-04-23 08:00 A | 2012-04-23 09:00 A |  | 0% → 100% | 143d → none |  | resources Carole Poland; Jun Cao; Hany Morcos → Carole Poland; Jun Cao; Hany Morcos; Dan Jump [50%]; baseline start none → 2012-04-23 08:00; baseline finish none → 2012-04-23 09:00 |
| 5 | Editorial staff meeting 4 | 2012-04-30 08:00 A | 2012-04-30 09:00 A |  | 0% → 100% | 138d → none |  | resources Carole Poland; Jun Cao; Hany Morcos → Carole Poland; Jun Cao; Hany Morcos; Dan Jump [50%]; baseline start none → 2012-04-30 08:00; baseline finish none → 2012-04-30 09:00 |
| 6 | Editorial staff meeting 5 | 2012-05-07 08:00 A | 2012-05-07 09:00 A |  | 0% → 100% | 133d → none |  | resources Carole Poland; Jun Cao; Hany Morcos → Carole Poland; Jun Cao; Hany Morcos; Dan Jump [50%]; baseline start none → 2012-05-07 08:00; baseline finish none → 2012-05-07 09:00 |
| 7 | Editorial staff meeting 6 | 2012-05-14 08:00 A | 2012-05-14 09:00 A |  | 0% → 100% | 128d → none |  | resources Carole Poland; Jun Cao; Hany Morcos → Carole Poland; Jun Cao; Hany Morcos; Dan Jump [50%]; baseline start none → 2012-05-14 08:00; baseline finish none → 2012-05-14 09:00 |
| 8 | Editorial staff meeting 7 | 2012-05-21 08:00 A | 2012-05-21 09:00 A |  | 0% → 100% | 123d → none |  | resources Carole Poland; Jun Cao; Hany Morcos → Carole Poland; Jun Cao; Hany Morcos; Dan Jump [50%]; baseline start none → 2012-05-21 08:00; baseline finish none → 2012-05-21 09:00 |
| 9 | Editorial staff meeting 8 |  |  |  |  | 118d → 123d |  | resources Carole Poland; Jun Cao; Hany Morcos → Carole Poland; Jun Cao; Hany Morcos; Dan Jump [50%]; baseline start none → 2012-05-28 08:00; baseline finish none → 2012-05-28 09:00 |
| 10 | Editorial staff meeting 9 |  |  |  |  | 113d → 118d |  | resources Carole Poland; Jun Cao; Hany Morcos → Carole Poland; Jun Cao; Hany Morcos; Dan Jump [50%]; baseline start none → 2012-06-04 08:00; baseline finish none → 2012-06-04 09:00 |
| 11 | Editorial staff meeting 10 |  |  |  |  | 108d → 113d |  | resources Carole Poland; Jun Cao; Hany Morcos → Carole Poland; Jun Cao; Hany Morcos; Dan Jump [50%]; baseline start none → 2012-06-11 08:00; baseline finish none → 2012-06-11 09:00 |
| 12 | Editorial staff meeting 11 |  |  |  |  | 103d → 108d |  | resources Carole Poland; Jun Cao; Hany Morcos → Carole Poland; Jun Cao; Hany Morcos; Dan Jump [50%]; baseline start none → 2012-06-18 08:00; baseline finish none → 2012-06-18 09:00 |
| 13 | Editorial staff meeting 12 |  |  |  |  | 98d → 103d |  | resources Carole Poland; Jun Cao; Hany Morcos → Carole Poland; Jun Cao; Hany Morcos; Dan Jump [50%]; baseline start none → 2012-06-25 08:00; baseline finish none → 2012-06-25 09:00 |
| 14 | Editorial staff meeting 13 |  |  |  |  | 93d → 98d |  | resources Carole Poland; Jun Cao; Hany Morcos → Carole Poland; Jun Cao; Hany Morcos; Dan Jump [50%]; baseline start none → 2012-07-02 08:00; baseline finish none → 2012-07-02 09:00 |
| 15 | **Acquisition** | 2012-04-02 08:00 A | 2012-05-11 17:00 → 2012-05-22 17:00 A (+11d) | 30d → 37d | 0% → 100% | -0.75d → none |  | baseline start none → 2012-04-02 08:00; baseline finish none → 2012-05-21 12:00 |
| 16 | Manuscript received | 2012-04-02 08:00 A | 2012-04-02 08:00 A |  | 0% → 100% | -9.5d → none |  | baseline start none → 2012-04-02 08:00; baseline finish none → 2012-04-02 08:00 |
| 17 | Content edit | 2012-04-02 08:00 A | 2012-04-25 17:00 → 2012-04-26 10:00 A (+1d) |  | 0% → 100% | -9.5d → none |  | baseline start none → 2012-04-02 08:00; baseline finish none → 2012-04-26 10:00 |
| 19 | Author review of content edit | 2012-04-26 08:00 → 2012-05-03 13:00 A (+7d) | 2012-05-11 17:00 → 2012-05-22 17:00 A (+11d) | 12d → 13d | 0% → 100% | -9.5d → none | 17 → 17, 18 | baseline start none → 2012-05-03 13:00; baseline finish none → 2012-05-21 12:00 |
| 20 | Handoff to Editorial | 2012-05-11 17:00 → 2012-05-22 17:00 A (+11d) | 2012-05-11 17:00 → 2012-05-22 17:00 A (+11d) |  | 0% → 100% | -9.5d → none |  | baseline start none → 2012-05-21 12:00; baseline finish none → 2012-05-21 12:00 |
| 21 | **Editorial** | 2012-05-10 08:00 → 2012-05-23 08:00 A (+13d) | 2012-06-20 17:00 → 2012-07-03 17:00 A (+13d) |  | 0% → 100% |  |  | baseline start none → 2012-05-21 13:00; baseline finish none → 2012-06-29 11:00 |
| 22 | Organize manuscript for copyedit | 2012-05-10 08:00 → 2012-05-23 08:00 A (+13d) | 2012-05-16 17:00 → 2012-05-29 17:00 A (+13d) |  | 0% → 100% | 1.25d → none |  | resources Hany Morcos → Hany Morcos; Dan Jump [50%]; baseline start none → 2012-05-21 13:00; baseline finish none → 2012-05-28 12:00 |
| 23 | Copyedit | 2012-05-17 08:00 → 2012-05-30 08:00 A (+13d) | 2012-06-01 10:00 → 2012-06-13 12:00 A (+12d) | 11.25d → 10.5d | 0% → 100% | 1.25d → none |  | baseline start none → 2012-05-28 13:00; baseline finish none → 2012-06-12 15:00 |
| 24 | Author review of copyedit | 2012-06-01 10:00 → 2012-06-13 13:00 A (+12d) | 2012-06-15 10:00 → 2012-06-29 17:00 A (+14d) | 10d → 12.5d | 0% → 100% | 1.25d → none |  | baseline start none → 2012-06-12 15:00; baseline finish none → 2012-06-26 15:00 |
| 25 | Copyedit incorp | 2012-06-12 15:00 → 2012-06-26 16:00 A (+14d) | 2012-06-19 15:00 → 2012-07-03 17:00 A (+14d) | 5d → 5.12d | 0% → 100% | 1.25d → none |  | resources Carole Poland → Carole Poland; Dan Jump [50%]; baseline start none → 2012-06-22 10:00; baseline finish none → 2012-06-29 11:00 |
| 26 | Handoff to Production | 2012-06-19 15:00 → 2012-07-03 17:00 A (+14d) | 2012-06-19 15:00 → 2012-07-03 17:00 A (+14d) |  | 0% → 100% | 1.25d → none |  | baseline start none → 2012-06-29 11:00; baseline finish none → 2012-06-29 11:00 |
| 27 | **Design and Production** | 2012-06-21 08:00 → 2012-07-05 08:00 A (+14d) | 2012-08-30 17:00 → 2012-09-20 11:12 (+21d) | 50d → 55.4d | 0% → 42% | 7d → -1.4d |  | baseline start none → 2012-06-29 11:00; baseline finish none → 2012-09-17 12:00 |
| 28 | Set pages | 2012-06-21 08:00 → 2012-07-05 08:00 A (+14d) | 2012-07-12 17:00 → 2012-07-25 15:12 A (+13d) | 15d → 14.78d | 0% → 100% | 7d → none |  | baseline start none → 2012-06-29 11:00; baseline finish none → 2012-07-23 11:00 |
| 29 | Interior illustration design | 2012-06-21 08:00 → 2012-07-05 08:00 A (+14d) | 2012-07-12 17:00 → 2012-07-25 17:00 A (+13d) |  | 0% → 100% | 7d → none |  | baseline start none → 2012-06-29 11:00; baseline finish none → 2012-07-23 12:00 |
| 30 | **1st Pages review** | 2012-07-13 08:00 → 2012-07-26 08:00 A (+13d) | 2012-08-16 17:00 → 2012-09-06 11:12 (+21d) | 25d → 30.4d | 0% → 7% | 7d → -1.4d |  | baseline start none → 2012-07-23 13:00; baseline finish none → 2012-09-03 12:00 |
| 31 | Proofread and index | 2012-07-13 08:00 → 2012-07-26 08:00 A (+13d) | 2012-07-26 17:00 → 2012-08-09 11:12 (+14d) | 10d → 10.4d | 0% → 19% | 33d → -1.4d |  | baseline start none → 2012-07-23 13:00; baseline finish none → 2012-08-06 12:00 |
| 32 | Incorporate 1st Pages review | 2012-07-27 08:00 → 2012-08-09 11:12 (+13d) | 2012-08-02 17:00 → 2012-08-23 11:12 (+21d) | 5d → 10d |  | 7d → -1.4d |  | resources Hany Morcos → Hany Morcos; Dan Jump [50%]; baseline start none → 2012-08-06 13:00; baseline finish none → 2012-08-20 12:00 |
| 33 | Send proofed pages to Production | 2012-08-02 17:00 → 2012-08-23 11:12 (+21d) | 2012-08-02 17:00 → 2012-08-23 11:12 (+21d) |  |  | 7d → -1.4d |  | baseline start none → 2012-08-20 12:00; baseline finish none → 2012-08-20 12:00 |
| 34 | Enter page corrections and index | 2012-08-03 08:00 → 2012-08-23 11:12 (+20d) | 2012-08-09 17:00 → 2012-08-30 11:12 (+21d) |  |  | 7d → -1.4d |  | resources Jane Dow → Jane Dow; Dan Jump [50%]; baseline start none → 2012-08-20 13:00; baseline finish none → 2012-08-27 12:00 |
| 35 | Cover design | 2012-08-10 08:00 → 2012-08-30 11:12 (+20d) | 2012-08-16 17:00 → 2012-09-06 11:12 (+21d) |  |  | 7d → -1.4d |  | baseline start none → 2012-08-27 13:00; baseline finish none → 2012-09-03 12:00 |
| 36 | **2nd Pages review** | 2012-08-17 08:00 → 2012-09-06 11:12 (+20d) | 2012-08-30 17:00 → 2012-09-20 11:12 (+21d) |  |  | 7d → -1.4d |  | baseline start none → 2012-09-03 13:00; baseline finish none → 2012-09-17 12:00 |
| 37 | Proof and review | 2012-08-17 08:00 → 2012-09-06 11:12 (+20d) | 2012-08-23 17:00 → 2012-09-13 11:12 (+21d) |  |  | 7d → -1.4d |  | baseline start none → 2012-09-03 13:00; baseline finish none → 2012-09-10 12:00 |
| 38 | Send proofed pages to Production | 2012-08-23 17:00 → 2012-09-13 11:12 (+21d) | 2012-08-23 17:00 → 2012-09-13 11:12 (+21d) |  |  | 7d → -1.4d |  | baseline start none → 2012-09-10 12:00; baseline finish none → 2012-09-10 12:00 |
| 39 | Final review | 2012-08-24 08:00 → 2012-09-13 11:12 (+20d) | 2012-08-30 17:00 → 2012-09-20 11:12 (+21d) |  |  | 7d → -1.4d |  | resources Jane Dow; Hany Morcos [50%]; Carole Poland [50%] → Jane Dow; Hany Morcos [50%]; Carole Poland [50%]; Bound galley proof [20 copy]; baseline start none → 2012-09-10 13:00; baseline finish none → 2012-09-17 12:00 |
| 40 | **Design book's companion website** | 2012-08-17 08:00 → 2012-09-06 11:12 (+20d) | 2012-08-23 17:00 → 2012-09-13 11:12 (+21d) |  |  | 12d → 3.6d |  | baseline start none → 2012-09-03 13:00; baseline finish none → 2012-09-10 12:00 |
| 41 | Create mockup | 2012-08-17 08:00 → 2012-09-06 11:12 (+20d) | 2012-08-21 17:00 → 2012-09-11 11:12 (+21d) |  |  | 12d → 3.6d |  | baseline start none → 2012-09-03 13:00; baseline finish none → 2012-09-06 12:00 |
| 42 | Review with author | 2012-08-22 08:00 → 2012-09-11 11:12 (+20d) | 2012-08-23 17:00 → 2012-09-13 11:12 (+21d) |  |  | 12d → 3.6d |  | resources Luis Sousa; Tad Orman → Luis Sousa; Tad Orman; Dan Jump [50%]; Travel [0.1%]; baseline start none → 2012-09-06 13:00; baseline finish none → 2012-09-10 12:00 |
| 43 | **Color prep and printing** | 2012-09-03 08:00 → 2012-09-24 08:00 (+21d) | 2012-11-09 17:00 → 2012-11-22 17:00 (+13d) | 50d → 44d |  | none → -3d |  | baseline start none → 2012-09-17 13:00; baseline finish none → 2012-11-16 12:00 |
| 44 | Send to color house | 2012-09-03 08:00 → 2012-09-24 08:00 (+21d) | 2012-09-03 17:00 → 2012-09-24 17:00 (+21d) |  |  | 4d → -1d |  | baseline start none → 2012-09-17 13:00; baseline finish none → 2012-09-18 12:00 |
| 45 | Generate proofs | 2012-09-04 08:00 → 2012-09-25 08:00 (+21d) | 2012-09-17 17:00 → 2012-10-08 17:00 (+21d) |  |  | 6d → -1d |  | baseline start none → 2012-09-18 13:00; baseline finish none → 2012-10-02 12:00 |
| 46 | Print and ship | 2012-09-21 08:00 → 2012-10-12 08:00 (+21d) | 2012-11-01 17:00 → 2012-11-22 17:00 (+21d) |  |  | 6d → 0d |  | baseline start none → 2012-10-05 13:00; baseline finish none → 2012-11-16 12:00 |
| 47 | **Book launch prep** | 2012-08-24 08:00 → 2012-09-25 08:00 (+32d) | 2012-09-17 17:00 → 2012-10-24 17:00 (+37d) | 17d → 22d |  | 39d → 21d |  | baseline start none → 2012-09-18 13:00; baseline finish none → 2012-10-18 12:00 |
| 48 | Launch planning | 2012-08-24 08:00 → 2012-09-25 08:00 (+32d) | 2012-08-30 17:00 → 2012-10-01 17:00 (+32d) |  |  | 39d → 21d | 40 → 44 | baseline start none → 2012-09-18 13:00; baseline finish none → 2012-09-25 12:00 |
| 49 | Assign launch team members | 2012-08-31 08:00 → 2012-10-02 08:00 (+32d) | 2012-08-31 17:00 → 2012-10-02 17:00 (+32d) |  |  | 39d → 21d |  | baseline start none → 2012-09-25 13:00; baseline finish none → 2012-09-26 12:00 |
| 50 | Complete author questionnaire | 2012-09-03 08:00 → 2012-10-03 08:00 (+30d) | 2012-09-07 17:00 → 2012-10-09 17:00 (+32d) |  |  | 39d → 21d |  | resources Hany Morcos; Tad Orman → Hany Morcos; Tad Orman; Travel [0.1%]; baseline start none → 2012-09-26 13:00; baseline finish none → 2012-10-03 12:00 |
| 51 | Schedule author interviews | 2012-09-10 08:00 → 2012-10-10 08:00 (+30d) | 2012-09-10 17:00 → 2012-10-10 17:00 (+30d) |  |  | 39d → 21d |  | baseline start none → 2012-10-03 13:00; baseline finish none → 2012-10-04 12:00 |
| 52 | Design and order marketing material | 2012-09-11 08:00 → 2012-10-11 08:00 (+30d) | 2012-09-17 17:00 → 2012-10-24 17:00 (+37d) | 5d → 10d |  | 39d → 21d |  | baseline start none → 2012-10-04 13:00; baseline finish none → 2012-10-18 12:00 |
